# 團購

Schedule from GanttProject, 2020-07-01 to 2020-12-15.
Holidays every year on 01-01, 02-28, 04-04, 05-01, 10-10

## Calendars

- Project calendar: Mon-Fri working; Sat-Sun off. Exceptions (off unless hours are given): 2020-10-01 (Mid-Aitumn), 2020-10-10 (10/10).

## Schedule

| ID | Task | Duration | Start | Finish |
| --- | --- | --- | --- | --- |
| 1 | 第一階段-規格確認 | 11d | 2020-07-01 | 2020-07-15 |
| 2 | 實際第一階段 | 11d | 2020-07-01 | 2020-07-15 |
| 3 | 第二階段-系統設定&發文 | 17d | 2020-07-16 | 2020-08-07 |
| 4 | 實際第二階段 | 30d | 2020-07-16 | 2020-08-26 |
| 5 | 第三階段-貼文&會員列表 | 14d | 2020-08-10 | 2020-08-27 |
| 6 | 實際第三階段 | 20d | 2020-08-18 | 2020-09-14 |
| 7 | 第四階段-到貨&訂單處理 | 17d | 2020-08-28 | 2020-09-21 |
| 8 | 實際第四階段 | 17d | 2020-09-10 | 2020-10-05 |
| 9 | 第五階段-各類報表 | 7d | 2020-09-22 | 2020-09-30 |
| 10 | 實際第五階段 | 10d | 2020-10-05 | 2020-10-16 |
| 11 | 第六階段-整合測試 | 21d | 2020-10-02 | 2020-10-30 |
| 12 | 第7階段-客戶測試&教育訓練&上線 | 32d | 2020-11-02 | 2020-12-15 |
